# Pixel_mechanics

Schedule from MS Project, 1999-10-01 to 2006-04-18, costs in $.
LBNL

## Calendars

- Standard: Mon-Fri 08:00-12:00, 13:00-17:00; Sat-Sun off.

## Resources

| Resource | Group | Rate |
| --- | --- | --- |
| LBLj SP PRJ | LBL | 67.53 |
| LBLj EE PRJ | LBL | 70.95 |
| LBLj ME PRJ | LBL | 70.95 |
| LBLj DS PRJ | LBL | 31.52 |
| LBLj ET PRJ | LBL | 31.52 |
| LBLj MT PRJ | LBL | 31.52 |
| LBLj AS PRJ | LBL | 30.01 |
| LBLj OA PRJ | LBL | 30.01 |
| LBLj CL PRJ | LBL | 20.02 |
| LBLj SH PRJ | LBL | 52.44 |
| LBLj TS PRJ | LBL | 52.44 |
| LBLj ST PRJ | LBL | 15.11 |
| LBLj PM PRJ | LBL | 0.11 |
| LBLj S PRJ | LBL |  |
| LBLj TR PRJ | LBL | 0.11 |
| LBLj LW PRJ | LBL | 0.11 |
| LBLj RD PRJ | LBL | 0.05 |
| LBLj HI PRJ | LBL | 0.05 |
| LBLs SP PRJ | LBL | 100 |
| LBLs EE PRJ | LBL | 105.06 |
| LBLs ME PRJ | LBL | 105.06 |
| LBLs DS PRJ | LBL | 49.96 |
| LBLs ET PRJ | LBL | 49.96 |
| LBLs MT PRJ | LBL | 49.96 |
| LBLs AS PRJ | LBL | 47.56 |
| LBLs OA PRJ | LBL | 47.56 |
| LBLs CL PRJ | LBL | 22.06 |
| LBLs SH PRJ | LBL | 52.44 |
| LBLs TS PRJ | LBL | 49.91 |
| LBLs ST PRJ | LBL | 15.11 |
| LBLs PM PRJ | LBL | 0.11 |
| LBLs S PRJ | LBL |  |
| LBLs TR PRJ | LBL | 0.11 |
| LBLs LW PRJ | LBL | 0.11 |
| LBLs RD PRJ | LBL | 0.05 |
| LBLs HI PRJ | LBL | 0.05 |
| SUNYA SP PRJ | SUNYA |  |
| SUNYA EE PRJ | SUNYA |  |
| SUNYA ME PRJ | SUNYA |  |
| SUNYA DS PRJ | SUNYA | 27.93 |
| SUNYA ET PRJ | SUNYA | 27.93 |
| SUNYA MT PRJ | SUNYA | 27.93 |
| SUNYA AS PRJ | SUNYA | 27.93 |
| SUNYA OA PRJ | SUNYA | 27.93 |
| SUNYA CL PRJ | SUNYA |  |
| SUNYA SH PRJ | SUNYA | 27.93 |
| SUNYA TS PRJ | SUNYA | 27.93 |
| SUNYA ST PRJ | SUNYA | 14.7 |
| SUNYA PM PRJ | SUNYA |  |
| SUNYA S PRJ | SUNYA |  |
| SUNYA TR PRJ | SUNYA |  |
| SUNYA LW PRJ | SUNYA |  |
| SUNYA RD PRJ | SUNYA | 0.47 |
| SUNYA HI PRJ | SUNYA |  |
| UNM SP PRJ | UNM | 40.32 |
| UNM EE PRJ | UNM | 43.95 |
| UNM ME PRJ | UNM | 40.32 |
| UNM DS PRJ | UNM | 22.68 |
| UNM ET PRJ | UNM | 22.68 |
| UNM MT PRJ | UNM | 22.68 |
| UNM AS PRJ | UNM | 22.68 |
| UNM OA PRJ | UNM | 22.68 |
| UNM CL PRJ | UNM | 18.9 |
| UNM SH PRJ | UNM | 49.14 |
| UNM TS PRJ | UNM | 49.14 |
| UNM ST PRJ | UNM | 10.99 |
| UNM PM PRJ | UNM |  |
| UNM S PRJ | UNM |  |
| UNM TR PRJ | UNM |  |
| UNM LW PRJ | UNM |  |
| UNM RD PRJ | UNM |  |
| UNM HI PRJ | UNM |  |
| UOK SP PRJ | UOK | 45.57 |
| UOK EE PRJ | UOK | 45.57 |
| UOK ME PRJ | UOK | 45.57 |
| UOK DS PRJ | UOK | 31.6 |
| UOK ET PRJ | UOK | 33.7 |
| UOK MT PRJ | UOK | 31.6 |
| UOK AS PRJ | UOK | 31.6 |
| UOK OA PRJ | UOK | 31.6 |
| UOK CL PRJ | UOK | 13.23 |
| UOK SH PRJ | UOK | 13.23 |
| UOK TS PRJ | UOK | 13.23 |
| UOK ST PRJ | UOK | 10.99 |
| UOK PM PRJ | UOK |  |
| UOK S PRJ | UOK |  |
| UOK TR PRJ | UOK | 0.15 |
| UOK LW PRJ | UOK |  |
| UOK RD PRJ | UOK |  |
| UOK HI PRJ | UOK |  |
| OSU PM PRJ | OSU |  |
| OSU LW PRJ | OSU |  |
| OSU ST PRJ | OSU | 11.61 |
| OSU ET PRJ | OSU | 36.5 |
| OSU EE PRJ | OSU | 66.36 |
| OSU CL PRJ | OSU | 21.56 |
| OSU MT PRJ | OSU | 36.5 |
| OSU HI PRJ | OSU |  |

## Schedule

| ID | WBS | Task | Type | Duration | Start | Finish | Predecessors | Total slack | Free slack | Constraint | Resources | Work | Cost |
| --- | --- | --- | --- | --- | --- | --- | --- | --- | --- | --- | --- | --- | --- |
| 1 | 1.1.1 | **US ATLAS Pixel Project** |  | 1707d | 1999-10-01 | 2006-04-18 |  | 0d |  |  |  | 35144.8h | 2,614,670.3 |
| 2 | 1.1.1.1 | **Mechanics** |  | 1707d | 1999-10-01 | 2006-04-18 |  | 0d |  |  |  | 9875h | 1,227,057.84 |
| 3 | 1.1.1.1.1 | **Design** |  | 1305d | 1999-10-01 | 2004-09-30 |  | 402d |  |  |  | 4400h | 356,758.8 |
| 4 | 1.1.1.1 | Mechanics Engineering FY03 $s |  | 261d | 2002-10-01 | 2003-09-30 |  | 620d |  | start no earlier than 2002-10-01 | LBLj DS PRJ [42.1%]; LBLj ME PRJ [84.3%]; LBLj EE PRJ [21.1%]; LBLj TR PRJ; LBLs DS PRJ [21.1%]; LBLs PM PRJ; LBLs TR PRJ | 3520h | 261,872 |
| 5 | 1.1.1.2 | Mechanics Engineering FY04 $s |  | 262d | 2003-10-01 | 2004-09-30 |  | 358d |  | start no earlier than 2003-10-01 | LBLj DS PRJ [21%]; LBLj ME PRJ [21%]; LBLj TR PRJ; LBLs TR PRJ | 880h | 82,886.8 |
| 6 | 1.1.1.3 | Mechanics Engineering FY05 $s | milestone | 0d | 1999-10-01 | 1999-10-01 |  | 1663d |  |  | LBLs TR PRJ |  | 12,000 |
| 7 | 1.1.1.4 | Support tube PRR | milestone | 0d | 2003-02-18 | 2003-02-18 |  | 420d | 0d | start no earlier than 2003-02-18 |  |  |  |
| 8 | 1.1.1.5 | Service panel/PP1 FDR | milestone | 0d | 2003-06-16 | 2003-06-16 |  | 741d |  | start no earlier than 2003-06-16 |  |  |  |
| 9 | 1.1.1.6 | Service panel/PP1 PRR | milestone | 0d | 2003-10-01 | 2003-10-01 |  | 394d | 0d | start no earlier than 2003-10-01 |  |  |  |
| 10 | 1.1.1.7 | Beam pipe support FDR | milestone | 0d | 2003-04-01 | 2003-04-01 |  | 795d |  | start no earlier than 2003-04-01 |  |  |  |
| 11 | 1.1.1.8 | Beam pipe support PRR | milestone | 0d | 2003-06-17 | 2003-06-17 |  | 421d | 0d | start no earlier than 2003-06-17 |  |  |  |
| 12 | 1.1.1.9 | Integration/Installation FDR | milestone | 0d | 2003-02-18 | 2003-02-18 |  | 825d |  | start no earlier than 2003-02-18 |  |  |  |
| 13 | 1.1.1.10 | Integration/Installation PRR | milestone | 0d | 2003-06-17 | 2003-06-17 |  | 740d |  | start no earlier than 2003-06-17 |  |  |  |
| 14 | 1.1.1.1.2 | **Development/Prototypes** |  | 240d | 2002-10-01 | 2003-09-01 |  | 685d |  |  |  |  |  |
| 15 | 1.1.2.1 | Development/Prototypes FY03 $s |  | 186d | 2002-10-01 | 2003-06-17 |  | 739d |  | start no earlier than 2002-10-01 |  |  |  |
| 16 | 1.1.2.2 | Support tube development/prototypes |  | 100d | 2002-10-01 | 2003-02-17 |  | 825d | 0d | start no earlier than 2002-10-01 |  |  |  |
| 17 | 1.1.2.3 | Support tube development complete | milestone | 0d | 2003-02-17 | 2003-02-17 | 16 | 825d |  |  |  |  |  |
| 18 | 1.1.2.4 | Service panel/PP1 development |  | 240d | 2002-10-01 | 2003-09-01 |  | 685d | 0d | start no earlier than 2002-10-01 |  |  |  |
| 19 | 1.1.2.5 | Service panel/PP1 development complete | milestone | 0d | 2003-09-01 | 2003-09-01 | 18 | 685d |  |  |  |  |  |
| 20 | 1.1.1.1.3 | **Production** |  | 925d | 2002-10-01 | 2006-04-18 |  | 0d |  |  |  | 5475h | 870,299.04 |
| 21 | 1.1.3.1 | Production FY03 $s |  | 261d | 2002-10-01 | 2003-09-30 |  | 620d |  | start no earlier than 2002-10-01 | LBLs ET PRJ [62.1%]; LBLs MT PRJ [27.9%]; LBLs SH PRJ [128.2%]; LBLs HI PRJ; LBLs PM PRJ; LBLs S PRJ; LBLj ET PRJ [17.3%]; LBLj SH PRJ [11.1%]; LBLj PM PRJ | 5149h | 769,799.6 |
| 22 | 1.1.3.2 | Production FY04 $s |  | 262d | 2003-10-01 | 2004-09-30 |  | 358d |  | start no earlier than 2003-10-01 | LBLs SH PRJ [15.6%]; LBLs PM PRJ; LBLs S PRJ | 326h | 93,821.44 |
| 23 | 1.1.3.3 | Production FY05 $s |  | 141d | 2004-10-01 | 2005-04-15 |  | 217d |  | start no earlier than 2004-10-01 | LBLs PM PRJ |  | 6,678 |
| 24 | 1.1.3.4 | Disk Sector Fabrication |  | 260d | 2002-10-01 | 2003-09-29 |  | 285d | 164d | start no earlier than 2002-10-01 |  |  |  |
| 25 | 1.1.3.5 | Support Frame Fabrication |  | 140d | 2002-10-01 | 2003-04-14 |  | 665d | 0d | start no earlier than 2002-10-01 |  |  |  |
| 26 | 1.1.3.6 | Support tube fabrication |  | 295d | 2003-04-29 | 2004-06-14 | 7FS+50d | 420d | 0d | start no earlier than 2002-04-15 |  |  |  |
| 27 | 1.1.3.7 | Service panel/PP1 fabrication |  | 260d | 2003-10-15 | 2004-10-12 | 9FS+10d | 394d |  |  |  |  |  |
| 28 | 1.1.3.8 | Trial Support Frame Assembly |  | 120d | 2003-04-15 | 2003-09-29 | 25 | 665d | 0d | start no earlier than 2001-08-03 |  |  |  |
| 29 | 1.1.3.9 | Support Frame Complete/Ready for Modules | milestone | 0d | 2003-09-29 | 2003-09-29 | 28 | 665d |  |  |  |  |  |
| 30 | 1.1.3.10 | Support Frame Needed for Modules | milestone | 0d | 2003-11-21 | 2003-11-21 | 141SS+10d | 626d |  |  |  |  |  |
| 31 | 1.1.3.11 | Disk Assembly/Test |  | 195d | 2004-03-29 | 2004-12-24 | 141SS+100d | 121d | 0d |  |  |  |  |
| 32 | Sil L2/9; Sil L3/1 | Disk System at CERN | milestone | 0d | 2005-01-21 | 2005-01-21 | 31FS+20d | 121d | 0d | start no earlier than 2003-04-03 |  |  |  |
| 33 | 1.1.3.13 | Beam pipe support fabrication |  | 249d | 2003-07-01 | 2004-06-11 | 11FS+10d | 421d | 1d |  |  |  |  |
| 34 | 1.1.3.14 | Trial assembly pixel package/PST |  | 45d | 2004-06-15 | 2004-08-16 | 33, 26 | 420d | 0d |  |  |  |  |
| 35 | 1.1.3.15 | PST at CERN | milestone | 0d | 2004-09-06 | 2004-09-06 | 34FS+15d | 420d |  |  |  |  |  |
| 36 | 1.1.3.16 | System Assembly/Test at CERN |  | 200d | 2005-01-24 | 2005-10-28 | 32 | 121d | 0d |  |  |  |  |
| 37 | 1.1.3.17 | Pixel System Ready for Installation | milestone | 0d | 2005-10-28 | 2005-10-28 | 36 | 121d |  |  |  |  |  |
| 38 | 1.1.3.18 | TC desired date for 2-layer system installation | milestone | 0d | 2006-01-02 | 2006-01-02 |  | 76d |  | finish no earlier than 2006-01-02 |  |  |  |
| 39 | 1.1.3.19 | Start pixel in-pit installation | milestone | 0d | 2006-04-18 | 2006-04-18 |  | 0d |  | start no earlier than 2006-04-18 |  |  |  |

Notes:
- 28: Trial assembly of frame sections and disk rings. B-layer structures not ready.
- 31: Disk is assembled as sectors are completed and tested. Disks inserted in frame as completed.
- 38: This is estimate. Final installation schedule not firm.

| ID | WBS | Task | Type | Duration | Start | Finish | Predecessors | Total slack | Free slack | Constraint | Resources | Work | Cost |
| --- | --- | --- | --- | --- | --- | --- | --- | --- | --- | --- | --- | --- | --- |
| 41 | 1.1.1.2 | **Sensors** |  | 600d | 2002-01-07 | 2004-04-23 |  | 516d |  |  |  | 1514.77h | 66,573.99 |
| 42 | 1.1.1.2.1 | **Design** |  | 326d | 2002-10-01 | 2003-12-30 |  | 599d |  |  |  | 1514.77h | 66,573.99 |
| 43 | 1.2.1.1 | Sensors Design FY03 $s |  | 260d | 2002-10-01 | 2003-09-29 |  | 621d |  | start no earlier than 2002-10-01 | UNM EE PRJ [41.6%] | 865.58h | 38,042.2 |
| 44 | 1.2.1.2 | Sensors Design FY04 $s |  | 65d | 2003-10-01 | 2003-12-30 |  | 555d |  | start no earlier than 2003-10-01 | UNM EE PRJ [124.8%] | 649.19h | 28,531.79 |
| 45 | 1.2.1.3 | Test Support |  | 325d | 2002-10-02 | 2003-12-30 |  | 599d |  | start no earlier than 2002-10-02 |  |  |  |
| 46 | 1.1.1.2.3 | **Production** |  | 600d | 2002-01-07 | 2004-04-23 |  | 516d |  |  |  |  |  |
| 47 | 1.2.2.1 | Sensors Production FY03 $s |  | 261d | 2002-10-01 | 2003-09-30 |  | 664d |  | start no earlier than 2002-10-01 |  |  |  |
| 48 | 1.2.2.2 | Sensors Production FY04 $s |  | 3d | 2003-10-01 | 2003-10-03 |  | 661d |  | start no earlier than 2003-10-01 |  |  |  |
| 49 | 1.2.2.3 | Sensors Production |  | 500d | 2002-01-07 | 2003-12-05 |  | 516d | 0d | start no earlier than 2002-01-07 |  |  |  |
| 50 | 1.2.2.4 | Sensors 50% production complete | milestone | 0d | 2003-07-01 | 2003-07-01 |  | 730d |  | start no earlier than 2003-07-01 |  |  |  |
| 51 | 1.2.2.5 | Sensor production complete | milestone | 0d | 2003-12-05 | 2003-12-05 | 49 | 616d |  | start no earlier than 2003-07-23 |  |  |  |
| 52 | 1.2.2.6 | Sensors Testing |  | 500d | 2002-05-27 | 2004-04-23 | 49SS+100d | 516d | 0d |  |  |  |  |
| 53 | 1.2.2.7 | Sensors Testing Complete | milestone | 0d | 2004-04-23 | 2004-04-23 | 52 | 516d |  |  |  |  |  |
| 54 | 1.2.2.8 | Sensors Need to Begin Module Production | milestone | 0d | 2004-02-12 | 2004-02-12 | 84SS | 568d |  |  |  |  |  |
| 56 | 1.1.1.3 | **Electronics** |  | 552d | 2002-10-01 | 2004-11-10 |  | 210d |  |  |  | 4260h | 380,375.6 |
| 57 | 1.1.1.3.1 | **Design** |  | 330d | 2002-10-01 | 2004-01-05 |  | 595d |  |  |  | 1320h | 161,479.2 |
| 58 | 1.3.1.1 | Elec.'s Design FY03 $s |  | 261d | 2002-10-01 | 2003-09-30 |  | 664d |  | start no earlier than 2002-10-01 | LBLs EE PRJ [63.2%]; LBLs TR PRJ; LBLj TR PRJ | 1320h | 161,479.2 |
| 59 | 1.3.1.2 | Elec.'s Design FY04 $s |  | 41d | 2003-10-01 | 2003-11-26 |  | 623d |  | start no earlier than 2003-10-01 |  |  |  |
| 60 | 1.3.1.3 | Front-end design |  | 330d | 2002-10-01 | 2004-01-05 |  | 595d |  | start no earlier than 2002-10-01 |  |  |  |
| 61 | 1.3.1.4 | IBM FE PRR | milestone | 0d | 2003-09-25 | 2003-09-25 |  | 373d | 0d | start no earlier than 2003-09-25 |  |  |  |
| 62 | 1.3.1.5 | Optical IC design |  | 330d | 2002-10-01 | 2004-01-05 |  | 595d |  | start no earlier than 2002-10-01 |  |  |  |
| 63 | 1.3.1.6 | Optical IC FDR | milestone | 0d | 2003-02-19 | 2003-02-19 |  | 824d | 0d | start no earlier than 2003-02-19 |  |  |  |
| 64 | 1.3.1.7 | Optical IC PRR | milestone | 0d | 2003-09-25 | 2003-09-25 | 61 | 413d | 0d |  |  |  |  |
| 65 | 1.1.1.3.2 | **Development/Prototypes** |  | 364d | 2002-10-01 | 2004-02-20 |  | 210d |  |  |  |  |  |
| 66 | 1.3.2.1 | Elec.'s Develop/Protos FY03 $s |  | 261d | 2002-10-01 | 2003-09-30 |  | 664d |  | start no earlier than 2002-10-01 |  |  |  |
| 67 | 1.3.2.2 | Elec.'s Develop/Protos FY04 $s |  | 12d | 2003-10-01 | 2003-10-16 |  | 652d |  | start no earlier than 2003-10-01 |  |  |  |
| 68 | 1.3.2.3 | 2nd IBM prototype submitted(FE-I2) | milestone | 0d | 2003-02-03 | 2003-02-03 |  | 121d | 0d | start no earlier than 2003-02-03 |  |  |  |
| 69 | 1.3.2.4 | 2nd IBM prototype 1st wafers delivered | milestone | 0d | 2003-05-02 | 2003-05-02 | 68FS+65d | 121d | 0d |  |  |  |  |
| 70 | 1.3.2.5 | Complete initial wafer probe FE-I2 | milestone | 0d | 2003-06-13 | 2003-06-13 | 69FS+30d | 121d | 0d |  |  |  |  |
| 71 | 1.3.2.6 | First bump bonded FE-I2assemblies arrive | milestone | 0d | 2003-07-11 | 2003-07-11 | 69SS+50d | 561d | 0d |  |  |  |  |
| 72 | 1.3.2.7 | Complete initial lab/system/ irradiation tests FE-I2 | milestone | 0d | 2003-09-19 | 2003-09-19 | 69FS+100d | 671d |  |  |  |  |  |
| 73 | 1.3.2.8 | Beam/system tests of FE-I2 assemblies |  | 160d | 2003-07-14 | 2004-02-20 | 71 | 561d |  | start no earlier than 2003-01-10 |  |  |  |

| ID | WBS | Task | Type | Duration | Start | Finish | Predecessors | Total slack | Free slack | Constraint | Resources | Work | Cost |
| --- | --- | --- | --- | --- | --- | --- | --- | --- | --- | --- | --- | --- | --- |
| 74 | 1.1.1.3.3 | **Production** |  | 552d | 2002-10-01 | 2004-11-10 |  | 373d |  |  |  | 2940h | 218,896.4 |
| 75 | 1.3.3.1 | Elec.'s Production FY03 $s |  | 261d | 2002-10-01 | 2003-09-30 |  | 664d |  | start no earlier than 2002-10-01 | LBLs CL PRJ [84.3%]; LBLs HI PRJ; LBLs PM PRJ; OSU HI PRJ; OSU LW PRJ; OSU ST PRJ [14.4%] | 2060h | 192,805.6 |
| 76 | 1.3.3.2 | Elec.'s Production FY04 $s |  | 206d | 2003-10-01 | 2004-07-14 |  | 458d |  | start no earlier than 2003-10-01 | LBLs CL PRJ [53.4%]; LBLs PM PRJ | 880h | 26,090.8 |
| 77 | Sil L2/7 | Start IBM Production | milestone | 0d | 2003-09-25 | 2003-09-25 | 61 | 373d | 0d | start no earlier than 2003-03-13 |  |  |  |
| 78 | 1.3.3.4 | FE IBM Production |  | 250d | 2003-09-25 | 2004-09-08 | 77 | 373d | 0d | start no earlier than 2001-09-03 |  |  |  |
| 79 | 1.3.3.5 | 1st FE IBM wafers arrive | milestone | 0d | 2004-02-11 | 2004-02-11 | 78SS+100d | 373d | 0d |  |  |  |  |
| 80 | 1.3.3.6 | 10% FE wafers complete | milestone | 0d | 2004-02-11 | 2004-02-11 | 79 | 468d | 0d |  |  |  |  |
| 81 | 1.3.3.7 | 25% FE wafers complete | milestone | 0d | 2004-02-11 | 2004-02-11 | 80 | 468d | 0d | start no earlier than 2003-12-15 |  |  |  |
| 82 | 1.3.3.8 | 50% FE wafers complete | milestone | 0d | 2004-06-30 | 2004-06-30 | 81FS+100d | 468d |  | start no earlier than 2004-03-15 |  |  |  |
| 83 | 1.3.3.9 | 100% FE wafers complete | milestone | 0d | 2004-09-08 | 2004-09-08 | 78FF | 418d |  |  |  |  |  |
| 84 | 1.3.3.10 | Test FE IBM wafers |  | 195d | 2004-02-12 | 2004-11-10 | 79 | 373d | 0d |  |  |  |  |
| 85 | 1.3.3.11 | FE Testing complete | milestone | 0d | 2004-11-10 | 2004-11-10 | 84 | 373d |  |  |  |  |  |
| 86 | 1.3.3.12 | Optical IC production |  | 100d | 2003-11-20 | 2004-04-07 | 64FS+40d | 483d | 0d |  |  |  |  |
| 87 | 1.3.3.13 | 1st Production Optical ICs | milestone | 0d | 2004-03-17 | 2004-03-17 | 86SS+85d | 483d | 0d |  |  |  |  |
| 88 | 1.3.3.14 | Test optical Ics |  | 60d | 2004-03-18 | 2004-06-09 | 87 | 483d | 0d |  |  |  |  |
| 89 | 1.3.3.15 | Optical IC testing complete | milestone | 0d | 2004-06-09 | 2004-06-09 | 88 | 483d |  |  |  |  |  |
| 91 | 1.1.1.4 | **Flex Hybrids/Optical Hybrids** |  | 773d | 2001-10-01 | 2004-09-15 |  | 413d |  |  |  | 3520h | 302,784.5 |
| 92 | 1.1.1.4.1 | **Design** |  | 261d | 2002-10-01 | 2003-09-30 |  | 595d |  |  |  |  | 8,790 |
| 93 | 1.4.1.1 | Hybrids Design FY03 $s |  | 261d | 2002-10-01 | 2003-09-30 |  | 664d |  | start no earlier than 2002-10-01 | UOK TR PRJ |  | 8,790 |
| 94 | 1.4.1.2 | Hybrids Design FY04 $s |  | 261d | 2002-10-01 | 2003-09-30 |  | 664d |  | start no earlier than 2002-10-01 |  |  |  |
| 95 | 1.4.1.3 | Award Bare Flex | milestone | 0d | 2003-03-10 | 2003-03-10 |  | 481d | 0d | start no earlier than 2003-03-10 |  |  |  |
| 96 | 1.4.1.4 | Optical FDR | milestone | 0d | 2003-02-19 | 2003-02-19 | 63 | 824d |  |  |  |  |  |
| 97 | 1.4.1.5 | Optical PRR | milestone | 0d | 2003-09-25 | 2003-09-25 | 64 | 413d | 0d | start no earlier than 2002-02-15 |  |  |  |
| 98 | 1.1.1.4.2 | **Development Prototypes** |  | 508d | 2001-10-01 | 2003-09-10 |  | 678d |  | start no earlier than 2000-07-18 |  |  |  |
| 99 | 1.4.2.1 | Hybrids Protos Fy03 $s |  | 13d | 2002-10-01 | 2002-10-17 |  | 912d |  | start no earlier than 2002-10-01 |  |  |  |
| 100 | 1.4.2.2 | Flex 3.x,4.x Fab and Test |  | 380d | 2001-10-01 | 2003-03-14 |  | 806d |  | start no earlier than 2001-10-01 |  |  |  |
| 101 | 1.4.2.3 | 3rd Optical Prototype Fab and Test |  | 150d | 2003-02-13 | 2003-09-10 | 97SS-160d | 678d |  |  |  |  |  |

Notes:
- 78: Assumes Temic. 265 wafers required.
- 84: About 4 wafers per day all sites.

| ID | WBS | Task | Type | Duration | Start | Finish | Predecessors | Total slack | Free slack | Constraint | Resources | Work | Cost |
| --- | --- | --- | --- | --- | --- | --- | --- | --- | --- | --- | --- | --- | --- |
| 102 | 1.1.1.4.3 | **Production** |  | 720d | 2001-12-13 | 2004-09-15 |  | 413d |  |  |  | 3520h | 293,994.5 |
| 103 | 1.4.3.1 | Hybrids Production FY02 $s |  | 208d | 2001-12-13 | 2002-09-30 |  | 925d |  | start no earlier than 2001-12-13 | SUNYA PM PRJ; UOK LW PRJ; OSU LW PRJ |  | 26,000 |
| 104 | 1.4.3.2 | Hybrids Production FY03 $s |  | 261d | 2002-10-01 | 2003-09-30 |  | 664d |  | start no earlier than 2002-10-01 | LBLs CL PRJ [13%]; LBLs PM PRJ; SUNYA ST PRJ [33.6%]; UOK ST PRJ [33.6%]; UOK ET PRJ [9.6%]; UOK HI PRJ; UOK LW PRJ; OSU ET PRJ [59.4%]; OSU ST PRJ [13.4%]; OSU LW PRJ | 3396h | 264,033.5 |
| 105 | 1.4.3.3 | Hybrids Production FY04 $s |  | 207d | 2003-10-01 | 2004-07-15 |  | 457d |  | start no earlier than 2003-10-01 | UOK ET PRJ [1.4%]; OSU ET PRJ [4.8%]; OSU ST PRJ [1.2%] | 124h | 3,961 |
| 106 | 1.4.3.4 | Flex Hybrid Production/Load |  | 250d | 2003-03-10 | 2004-02-20 | 95 | 481d | 0d |  |  |  |  |
| 107 | 1.4.3.5 | First flex delivered | milestone | 0d | 2003-06-27 | 2003-06-27 | 106SS+80d | 481d | 0d |  |  |  |  |
| 108 | 1.4.3.6 | 10% flex complete | milestone | 0d | 2003-07-25 | 2003-07-25 | 107FS+20d | 561d | 0d | start no earlier than 2003-04-01 |  |  |  |
| 109 | 1.4.3.7 | 25% flex complete | milestone | 0d | 2003-10-03 | 2003-10-03 | 108FS+50d | 561d | 0d | start no earlier than 2003-05-15 |  |  |  |
| 110 | 1.4.3.8 | 50% flex complete | milestone | 0d | 2003-12-12 | 2003-12-12 | 109FS+50d | 561d | 0d | start no earlier than 2003-07-15 |  |  |  |
| 111 | 1.4.3.9 | Flex complete | milestone | 0d | 2004-02-20 | 2004-02-20 | 110FS+50d | 561d |  | start no earlier than 2003-07-15 |  |  |  |
| 112 | 1.4.3.10 | Flex testing |  | 250d | 2003-06-30 | 2004-06-11 | 107 | 481d | 0d |  |  |  |  |
| 113 | 1.4.3.11 | First flex available for module assembly | milestone | 0d | 2003-07-11 | 2003-07-11 | 107FS+10d | 721d |  |  |  |  |  |
| 114 | 1.4.3.12 | Need date for first flex | milestone | 0d | 2003-07-11 | 2003-07-11 | 71 | 721d |  |  |  |  |  |
| 115 | 1.4.3.13 | Flex testing complete | milestone | 0d | 2004-06-11 | 2004-06-11 | 112 | 481d |  |  |  |  |  |
| 116 | 1.4.3.14 | Optical Production |  | 235d | 2003-10-23 | 2004-09-15 | 97FS+20d | 413d | 0d |  |  |  |  |
| 117 | 1.4.3.15 | First optical boards | milestone | 0d | 2004-03-10 | 2004-03-10 | 116SS+100d | 548d |  |  |  |  |  |
| 118 | 1.4.3.16 | Optical production complete | milestone | 0d | 2004-09-15 | 2004-09-15 | 116 | 413d |  |  |  |  |  |
| 120 | 1.1.1.5 | **Modules** |  | 549d | 2002-10-01 | 2004-11-05 |  | 325d |  |  |  | 15975h | 582,228.37 |
| 121 | 1.1.1.5.1 | **Design** |  | 261d | 2002-10-01 | 2003-10-01 |  | 664d |  |  |  |  |  |
| 122 | 1.5.1.1 | Modules Design FY03 $s |  | 212d | 2002-10-01 | 2003-07-23 |  | 713d |  | start no earlier than 2002-10-01 |  |  |  |
| 123 | 1.5.1.2 | Module assembly PRR | milestone | 0d | 2003-10-01 | 2003-10-01 |  | 664d |  | start no earlier than 2003-10-01 |  |  |  |
| 124 | 1.1.1.5.2 | **Development/Prototypes** |  | 190d | 2002-10-01 | 2003-06-23 |  | 735d |  |  |  | 1728h | 46,054.76 |
| 125 | 1.5.2.1 | Modules Protos FY03 $s |  | 172d | 2002-10-01 | 2003-05-28 |  | 753d |  | start no earlier than 2002-10-01 | LBLj ET PRJ [16%]; LBLj MT PRJ [38.4%]; LBLj ST PRJ [64%]; LBLj S PRJ; LBLs ST PRJ [7.3%]; LBLs PM PRJ | 1728h | 46,054.76 |
| 126 | 1.5.2.2 | Prototype module fab/test |  | 190d | 2002-10-01 | 2003-06-23 |  | 735d |  | start no earlier than 2002-10-01 |  |  |  |

| ID | WBS | Task | Type | Duration | Start | Finish | Predecessors | Total slack | Free slack | Constraint | Resources | Work | Cost |
| --- | --- | --- | --- | --- | --- | --- | --- | --- | --- | --- | --- | --- | --- |
| 127 | 1.1.1.5.3 | **Production** |  | 345d | 2003-07-14 | 2004-11-05 |  | 121d |  |  |  | 14247h | 536,173.61 |
| 128 | 1.5.3.1 | Modules Production FY03 $s |  | 24d | 2003-08-28 | 2003-09-30 |  | 664d |  | start no earlier than 2003-08-28 | LBLj ST PRJ [1947.9%]; LBLj PM PRJ; LBLs CL PRJ [916.7%]; LBLs ET PRJ [93.8%]; LBLs MT PRJ [93.8%]; LBLs SH PRJ [156.8%]; LBLs ST PRJ [916.7%]; LBLs PM PRJ; OSU CL PRJ [306.8%]; OSU MT PRJ [306.8%]; OSU LW PRJ | 9099h | 345,935.98 |
| 129 | 1.5.3.2 | Modules Production FY04 $s |  | 262d | 2003-10-01 | 2004-09-30 |  | 402d |  | start no earlier than 2003-10-01 | LBLj ST PRJ [94.5%]; LBLj PM PRJ; LBLs CL PRJ [28.1%]; LBLs ET PRJ [33.4%]; LBLs MT PRJ [33.4%]; LBLs ST PRJ [28.1%]; LBLs PM PRJ; OSU CL PRJ [14.1%]; OSU MT PRJ [14.1%]; OSU LW PRJ | 5148h | 190,237.63 |
| 130 | 1.5.3.3 | Modules Production FY05 $s |  | 9d | 2004-10-01 | 2004-10-13 |  | 393d |  | start no earlier than 2004-10-01 |  |  |  |
| 131 | 1.5.3.4 | FE Wafer Bump Deposition |  | 260d | 2003-07-14 | 2004-07-09 | 70FS+20d | 121d | 0d |  |  |  |  |
| 132 | 1.5.3.5 | FE wafer thinning |  | 260d | 2003-08-11 | 2004-08-06 | 131SS+20d | 121d | 0d |  |  |  |  |
| 133 | 1.5.3.6 | FE Wafer Dicing |  | 260d | 2003-08-18 | 2004-08-13 | 132SS+5d | 121d | 0d |  |  |  |  |
| 134 | 1.5.3.7 | FE Die sort |  | 260d | 2003-08-25 | 2004-08-20 | 133SS+5d | 121d | 0d |  |  |  |  |
| 135 | Sil L2/8 | Start bare module production | milestone | 0d | 2003-09-05 | 2003-09-05 | 134SS+10d | 121d | 0d |  |  |  |  |
| 136 | 1.5.3.9 | Bare module production |  | 260d | 2003-09-08 | 2004-09-03 | 135 | 121d | 0d |  |  |  |  |
| 137 | 1.5.3.10 | Bare module testing |  | 260d | 2003-10-06 | 2004-10-01 | 136SS+20d | 121d | 0d |  |  |  |  |
| 138 | 1.5.3.11 | Module assembly/test |  | 260d | 2003-10-20 | 2004-10-15 | 137SS+10d | 121d | 0d |  |  |  |  |
| 139 | 1.5.3.12 | Complete testing IBM outer modules | milestone | 0d | 2004-10-15 | 2004-10-15 | 138 | 391d |  |  |  |  |  |
| 140 | 1.5.3.13 | Module attach to disk sectors |  | 260d | 2003-11-03 | 2004-10-29 | 24SS+120d, 138SS+10d | 121d | 0d |  |  |  |  |
| 141 | 1.5.3.14 | Test disk sectors |  | 260d | 2003-11-10 | 2004-11-05 | 140SS+5d | 121d | 0d |  |  |  |  |
| 142 | 1.5.3.15 | Complete testing disk sectors | milestone | 0d | 2004-11-05 | 2004-11-05 | 141 | 376d |  |  |  |  |  |
| 144 | 1.1.1.6 | **Beam/System Test Support** |  | 784d | 2002-10-01 | 2005-09-30 |  | 141d |  |  |  |  | 55,650 |
| 145 | 1.6.1 | **Test Beam Support** |  | 259d | 2002-10-01 | 2003-09-26 |  | 666d |  |  |  |  | 16,695 |
| 146 | 1.6.1.1 | Test Beam Support FY03 $s |  | 259d | 2002-10-01 | 2003-09-26 |  | 666d |  | start no earlier than 2002-10-01 | LBLj PM PRJ |  | 16,695 |
| 147 | 1.6.2 | **System Test Support** |  | 784d | 2002-10-01 | 2005-09-30 |  | 141d |  |  |  |  | 38,955 |
| 148 | 1.6.2.1 | System Test Support FY03 $s |  | 261d | 2002-10-01 | 2003-09-30 |  | 664d |  | start no earlier than 2002-10-01 | LBLj PM PRJ |  | 16,695 |
| 149 | 1.6.2.2 | System Test Support FY04$s |  | 262d | 2003-10-01 | 2004-09-30 |  | 402d |  | start no earlier than 2003-10-01 | LBLj PM PRJ |  | 11,130 |
| 150 | 1.6.2.3 | System Test Support FY05 $s |  | 261d | 2004-10-01 | 2005-09-30 |  | 141d |  | start no earlier than 2004-10-01 | LBLj PM PRJ |  | 11,130 |

Notes:
- 131: Includes B-layer
- 132: Includes B-layer
- 133: Includes B-layer
- 134: Includes B-layer
- 136: About 35 modules per week. Peak rate from two vendors is expected to be 40 modules per week.
- 137: About 35 modules per week.
- 138: About 35 modules per week.
- 140: About one sector every four days. This is about 1/2 of expected rate.
- 141: About one sector every four days. This is about 1/2 of expected rate.
